# GISMO 20060818

Schedule from MS Project, 2006-08-17 to 2006-12-12.
Carnegie Observatories

## Calendars

- Standard: Mon-Fri 08:00-12:00, 13:00-17:00; Sat-Sun off.

## Schedule

| ID | WBS | Task | Type | Duration | Start | Finish | Predecessors | Total slack | Free slack | Constraint |
| --- | --- | --- | --- | --- | --- | --- | --- | --- | --- | --- |
| 1 | 1 | **Preliminary mechanical design** |  | 73d? | 2006-08-17 | 2006-11-27 |  | 0d |  |  |
| 2 | 1.1 | Optical mount concept | milestone | 0d | 2006-08-17 | 2006-08-17 |  | 73d |  |  |
| 3 | 1.2 | **Mask slide mechanism concept** |  | 1d? | 2006-08-17 | 2006-08-17 |  | 72d |  |  |
| 4 | 1.2.1 | Mask holder concept |  | 1d? | 2006-08-17 | 2006-08-17 |  | 72d |  |  |
| 5 | 1.2.2 | Bearing selection | milestone | 0d | 2006-08-17 | 2006-08-17 |  | 73d |  |  |
| 6 | 1.2.3 | Motor selection | milestone | 0d | 2006-08-17 | 2006-08-17 |  | 73d |  |  |
| 7 | 1.2.4 | Controllers selection |  | 1d | 2006-08-17 | 2006-08-17 |  | 72d |  |  |
| 8 | 1.2.5 | Brake selection | milestone | 0d | 2006-08-17 | 2006-08-17 |  | 73d |  |  |
| 9 | 1.3 | Housing concept |  | 1d? | 2006-08-17 | 2006-08-17 |  | 72d |  |  |
| 10 | 1.4 | **Controls concept** |  | 1d? | 2006-08-17 | 2006-08-17 |  | 72d |  |  |
| 11 | 1.4.1 | Wiring preliminary design |  | 1d? | 2006-08-17 | 2006-08-17 |  | 72d |  |  |
| 12 | 1.4.2 | Control sequencing logic for software |  | 1d? | 2006-08-17 | 2006-08-17 |  | 72d | 0d |  |
| 13 | 1.5 | **Electric connector selection** |  | 73d? | 2006-08-17 | 2006-11-27 |  | 0d |  |  |
| 14 | 1.5.1 | Determine number of pins |  | 56d? | 2006-09-11 | 2006-11-27 |  | 0d |  | finish no earlier than 2006-11-27 |
| 15 | 1.5.2 | Obtain sample connectors |  | 1d? | 2006-08-17 | 2006-08-17 |  | 72d |  |  |
| 16 | 1.5.3 | Evaluate connectors |  | 1d? | 2006-08-17 | 2006-08-17 |  | 72d |  |  |
| 17 | 1.5.4 | Connector selection |  | 1d? | 2006-08-17 | 2006-08-17 |  | 72d |  |  |
| 18 | 1.6 | **IMACS modifications design** |  | 1d? | 2006-08-17 | 2006-08-17 |  | 72d |  |  |
| 19 | 1.6.1 | Electrical connector housing design |  | 1d? | 2006-08-17 | 2006-08-17 |  | 72d |  |  |
| 20 | 1.6.2 | Rack space allocation |  | 1d? | 2006-08-17 | 2006-08-17 |  | 72d |  |  |
| 21 | 1.6.3 | Instrument team review of IMACS mods |  | 1d? | 2006-08-17 | 2006-08-17 |  | 72d |  |  |
| 22 | 1.6.4 | Evaluate air cylinder capacity |  | 1d? | 2006-08-17 | 2006-08-17 |  | 72d |  |  |
| 23 | 2 | Design review | milestone | 0d | 2006-11-27 | 2006-11-27 | 1 | 10d | 0d |  |
| 24 | 3 | Modifications due to design review |  | 1d? | 2006-11-28 | 2006-11-28 | 23 | 10d |  |  |

| ID | WBS | Task | Duration | Start | Finish | Predecessors | Total slack | Free slack |
| --- | --- | --- | --- | --- | --- | --- | --- | --- |
| 25 | 4 | **Slitmask hardware** | 6d? | 2006-08-17 | 2006-08-24 |  | 78d |  |
| 26 | 4.1 | Select material/vendor | 1d? | 2006-08-17 | 2006-08-17 |  | 78d | 0d |
| 27 | 4.2 | Obtain material sample | 1d? | 2006-08-18 | 2006-08-18 | 26 | 78d | 0d |
| 28 | 4.3 | Design mask blank | 1d? | 2006-08-21 | 2006-08-21 | 27 | 78d | 0d |
| 29 | 4.4 | Design mask holder for laser | 1d? | 2006-08-22 | 2006-08-22 | 28 | 78d | 0d |
| 30 | 4.5 | Build holder | 1d? | 2006-08-23 | 2006-08-23 | 29 | 78d | 0d |
| 31 | 4.6 | Test holder in laser machine | 1d? | 2006-08-24 | 2006-08-24 | 30, 41 | 78d |  |
| 32 | 5 | **Long lead-time orders** | 1d? | 2006-08-17 | 2006-08-17 |  | 83d |  |
| 33 | 5.1 | Electronics chassis | 1d? | 2006-08-17 | 2006-08-17 |  | 83d |  |
| 34 | 6 | Alignment plan | 1d? | 2006-08-17 | 2006-08-17 |  | 83d |  |
| 35 | 7 | **Construction** | 2d? | 2006-11-28 | 2006-11-29 | 1 | 0d |  |
| 36 | 7.1 | Shop drawings | 1d? | 2006-11-28 | 2006-11-28 |  | 0d |  |
| 37 | 7.2 | Manufacturing | 1d? | 2006-11-29 | 2006-11-29 | 36 | 0d |  |
| 38 | 7.3 | Purchase hardware & materials | 1d? | 2006-11-28 | 2006-11-28 |  | 1d |  |
| 39 | 8 | **Software** | 2d? | 2006-08-18 | 2006-08-21 | 12 | 80d |  |
| 40 | 8.1 | Design laser cutter software | 1d? | 2006-08-18 | 2006-08-18 |  | 80d | 0d |
| 41 | 8.2 | Laser cutter software | 1d? | 2006-08-21 | 2006-08-21 | 40 | 80d | 2d |
| 42 | 8.3 | Implement controls logic | 1d? | 2006-08-18 | 2006-08-18 |  | 81d | 0d |
| 43 | 8.4 | Test controls | 1d? | 2006-08-21 | 2006-08-21 | 42 | 81d |  |
| 44 | 9 | Integrate | 1d? | 2006-11-30 | 2006-11-30 | 35 | 0d |  |
| 45 | 10 | Test | 1d? | 2006-12-01 | 2006-12-01 | 44 | 0d |  |
| 46 | 11 | **Commissioning plan** | 3d? | 2006-08-17 | 2006-08-21 |  | 74d |  |
| 47 | 11.1 | Draft commissioning plan | 1d? | 2006-08-17 | 2006-08-17 |  | 74d | 0d |
| 48 | 11.2 | Review with observatory staff | 1d? | 2006-08-18 | 2006-08-18 | 47 | 74d | 0d |
| 49 | 11.3 | Revise commissioning plan | 1d? | 2006-08-21 | 2006-08-21 | 48 | 74d |  |

| ID | WBS | Task | Duration | Start | Finish | Predecessors | Total slack |
| --- | --- | --- | --- | --- | --- | --- | --- |
| 50 | 12 | **Documentation** | 1d? | 2006-08-17 | 2006-08-17 |  | 83d |
| 51 | 12.1 | Mech/elec/optical schematics & drawings | 1d? | 2006-08-17 | 2006-08-17 |  | 83d |
| 52 | 12.2 | Service manual | 1d? | 2006-08-17 | 2006-08-17 |  | 83d |
| 53 | 12.3 | Users manual | 1d? | 2006-08-17 | 2006-08-17 |  | 83d |
| 54 | 13 | **Pre-ship review** | 3d? | 2006-12-04 | 2006-12-06 | 46, 45 | 0d |
| 55 | 13.1 | Set pre-ship review date | 1d? | 2006-12-04 | 2006-12-04 | 44 | 0d |
| 56 | 13.2 | Pre-ship review done | 1d? | 2006-12-05 | 2006-12-05 | 55 | 0d |
| 57 | 13.3 | Review response & modifications | 1d? | 2006-12-06 | 2006-12-06 | 56 | 0d |
| 58 | 14 | **Shipping** | 3d? | 2006-12-07 | 2006-12-11 | 57 | 0d |
| 59 | 14.1 | Write shipping manifest | 1d? | 2006-12-07 | 2006-12-07 |  | 0d |
| 60 | 14.2 | Design/build shipping containers | 1d? | 2006-12-08 | 2006-12-08 | 59 | 0d |
| 61 | 14.3 | Pack and airship | 1d? | 2006-12-11 | 2006-12-11 | 60 | 1d |
| 62 | 15 | Installation | 1d? | 2006-12-11 | 2006-12-11 | 60 | 0d |
| 63 | 16 | Commissioning | 1d? | 2006-12-12 | 2006-12-12 | 62 | 0d |
